# CSM opgaver Pernille

Schedule from MS Project, 2026-01-05 to 2026-10-20.

## Calendars

- Standard: Mon-Fri 08:00-12:00, 13:00-17:00; Sat-Sun off.

## Resources

| Resource |
| --- |
| COWI? |
| Rambøll |
| TOEL |
| PEMO |
| Sweco |
| ? |
| COWI |
| AFRY |
| Atkins |
| Møller-Lassen |
| Ansøger |
| PRO |
| LT PRO |
| LT SIK |
| LT TSA |
| 3.part |
| LT TRA |

## Schedule

| ID | WBS | Task | Type | Duration | Start | Finish | Predecessors | Total slack | Constraint | Resources | Work |
| --- | --- | --- | --- | --- | --- | --- | --- | --- | --- | --- | --- |
| 1 | 1 | **Projektdokumenter** |  | 16d | 2026-01-05 | 2026-01-26 |  | 0d |  |  | 128h |
| 2 | 1.1 | Projektkoordinator og projektleder udarbejder Projektdokumenter |  | 1d | 2026-01-05 | 2026-01-05 |  | 0d | start no earlier than 2026-01-05 | 3.part | 8h |
| 3 | 1.2 | Review hos Lokaltog | milestone | 0d | 2026-01-05 | 2026-01-05 | 2 | 0d |  | LT PRO |  |
| 4 | 1.3 | Opdatering iht. kommentarer | milestone | 0d | 2026-01-05 | 2026-01-05 | 3 | 0d |  | 3.part |  |
| 5 | 1.4 | Review hos Lokaltog | milestone | 0d | 2026-01-05 | 2026-01-05 | 4 | 0d |  | LT PRO |  |
| 6 | 1.5 | Opdatering iht. kommentarer | milestone | 0d | 2026-01-05 | 2026-01-05 | 5 | 0d |  | 3.part |  |
| 7 | 1.6 | Lokaltog fremsender godkendelse |  | 15d | 2026-01-06 | 2026-01-26 | 6 | 0d |  | LT TSA | 120h |
| 8 | 2 | **Faglig Ledelse** |  | 46d | 2026-01-27 | 2026-03-31 |  | 0d |  |  | 368h |
| 9 | 2.1 | Projekteringsleder og projektkoordinator udarbejder dokumenter til Faglig Ledelse |  | 1d | 2026-01-27 | 2026-01-27 | 7 | 0d |  | 3.part | 8h |
| 10 | 2.2 | Review hos Lokaltog |  | 15d | 2026-01-28 | 2026-02-17 | 9 | 0d |  | LT PRO | 120h |
| 11 | 2.3 | Faglig Ledelse hos Lokaltog | milestone | 0d | 2026-02-17 | 2026-02-17 | 10 | 0d |  | LT TSA |  |
| 12 | 2.4 | Opdatering iht. kommentarer | milestone | 0d | 2026-02-17 | 2026-02-17 | 11 | 0d |  | 3.part |  |
| 13 | 2.5 | Review hos Lokaltog | milestone | 0d | 2026-02-17 | 2026-02-17 | 12 | 0d |  | LT PRO |  |
| 14 | 2.6 | Faglig Ledelse hos Lokaltog | milestone | 0d | 2026-02-17 | 2026-02-17 | 13 | 0d |  | LT TSA |  |
| 15 | 2.7 | Opdatering iht. kommentarer | milestone | 0d | 2026-02-17 | 2026-02-17 | 14 | 0d |  | 3.part |  |
| 16 | 2.8 | TSA, Banemester og Sikringsmester gennemfører Faglig Ledelse |  | 15d | 2026-02-18 | 2026-03-10 | 15 | 0d |  | LT TSA | 120h |
| 17 | 2.9 | Lokaltog fremsender godkendelse |  | 15d | 2026-03-11 | 2026-03-31 | 16 | 0d |  | LT PRO | 120h |
| 18 | 3 | **Sikkerhedspakke** |  | 46d | 2026-04-01 | 2026-06-03 |  | 0d |  |  | 368h |
| 19 | 3.1 | CSM ansvarlig, projektkoordinator og projektleder udarbejder dokumenter til Sikkerhedspakken |  | 1d | 2026-04-01 | 2026-04-01 | 17 | 0d |  | 3.part | 8h |
| 20 | 3.2 | Review hos Lokaltog | milestone | 0d | 2026-04-01 | 2026-04-01 | 19 | 0d |  | LT PRO |  |
| 21 | 3.3 | Opdatering iht. kommentarer | milestone | 0d | 2026-04-01 | 2026-04-01 | 20 | 0d |  | 3.part |  |
| 22 | 3.4 | Review hos Lokaltog | milestone | 0d | 2026-04-01 | 2026-04-01 | 21 | 0d |  | LT PRO |  |
| 23 | 3.5 | Opdatering iht. kommentarer | milestone | 0d | 2026-04-01 | 2026-04-01 | 22 | 0d |  | 3.part; ?; AFRY; Ansøger; Atkins; COWI; COWI?; LT PRO; LT SIK; LT TRA; LT TSA; Møller-Lassen; PEMO; PRO; Rambøll; Sweco; TOEL |  |
| 24 | 3.6 | Sikkerhedspakke sendes til Sikkerhed |  | 15d | 2026-04-02 | 2026-04-22 | 23 | 0d |  | LT PRO | 120h |
| 25 | 3.7 | Behandling hos Sikkerhed | milestone | 0d | 2026-04-22 | 2026-04-22 | 24 | 0d |  | LT SIK |  |
| 26 | 3.8 | Opdatering iht. kommentarer | milestone | 0d | 2026-04-22 | 2026-04-22 | 25 | 0d |  | 3.part |  |
| 27 | 3.9 | Behandling hos Sikkerhed | milestone | 0d | 2026-04-22 | 2026-04-22 | 26 | 0d |  | LT SIK |  |
| 28 | 3.10 | Opdatering iht. kommentarer | milestone | 0d | 2026-04-22 | 2026-04-22 | 27 | 0d |  | 3.part |  |
| 29 | 3.11 | Sikkerhed udsteder Ibrugtagningstilkendegivelse (IBTK) |  | 15d | 2026-04-23 | 2026-05-13 | 28 | 0d |  | LT SIK | 120h |
| 30 | 3.12 | Lokaltog fremsender IBTK |  | 15d | 2026-05-14 | 2026-06-03 | 29 | 0d |  | LT PRO | 120h |

| ID | WBS | Task | Type | Duration | Start | Finish | Predecessors | Total slack | Resources | Work |
| --- | --- | --- | --- | --- | --- | --- | --- | --- | --- | --- |
| 31 | 4 | **Udførelse** |  | 47d | 2026-06-04 | 2026-08-07 |  | 0d |  | 368h |
| 32 | 4.1 | Projektleder og SR-arbejdsleder udarbejder udførelsesdokumenter |  | 1d | 2026-06-04 | 2026-06-04 | 30 | 0d | 3.part | 8h |
| 33 | 4.2 | Review hos Lokaltog | milestone | 0d | 2026-06-04 | 2026-06-04 | 32 | 0d | LT PRO |  |
| 34 | 4.3 | Opdatering iht. kommentarer | milestone | 0d | 2026-06-04 | 2026-06-04 | 33 | 0d | 3.part |  |
| 35 | 4.4 | Review hos Lokaltog | milestone | 0d | 2026-06-04 | 2026-06-04 | 34 | 0d | LT PRO |  |
| 36 | 4.5 | Opdatering iht. kommentarer | milestone | 0d | 2026-06-04 | 2026-06-04 | 35 | 0d | 3.part |  |
| 37 | 4.6 | Dokumenter sendes til Trafik |  | 15d | 2026-06-05 | 2026-06-25 | 36 | 0d | LT PRO | 120h |
| 38 | 4.7 | Behandling hos Trafik | milestone | 0d | 2026-06-25 | 2026-06-25 | 37 | 0d | LT SIK |  |
| 39 | 4.8 | Opdatering iht. kommentarer | milestone | 0d | 2026-06-25 | 2026-06-25 | 38 | 0d | 3.part |  |
| 40 | 4.9 | Behandling hos Trafik | milestone | 0d | 2026-06-25 | 2026-06-25 | 39 | 0d | LT SIK |  |
| 41 | 4.10 | Opdatering iht. kommentarer | milestone | 0d | 2026-06-25 | 2026-06-25 | 40 | 0d | 3.part |  |
| 42 | 4.11 | Trafik godkender udførelsesdokumenter |  | 15d | 2026-06-26 | 2026-07-16 | 41 | 0d | LT SIK | 120h |
| 43 | 4.12 | Lokaltog fremsender godkendelse |  | 15d | 2026-07-17 | 2026-08-06 | 42 | 0d | LT PRO | 120h |
| 44 | 4.13 | Projektleder, entreprenør og SR-arbejdsleder forestår udførelse og ibrugtagning |  | 1d | 2026-08-07 | 2026-08-07 | 43 | 0d |  |  |
| 45 | 5 | **Tillæg 1 (Til Sikkerhed senest 6 uger efter ibrugtagning)** |  | 52d | 2026-08-10 | 2026-10-20 |  | 0d |  | 416h |
| 46 | 5.1 | Projektleder, entreprenør, CSM ansvarlig og projektkoordinator udarbejder dokumenter til Tillæg 1 |  | 1d | 2026-08-10 | 2026-08-10 | 44 | 0d | 3.part | 8h |
| 47 | 5.2 | Review hos Lokaltog |  | 10d | 2026-08-11 | 2026-08-24 | 46 | 0d | LT PRO | 80h |
| 48 | 5.3 | Opdatering iht. kommentarer |  | 1d | 2026-08-25 | 2026-08-25 | 47 | 0d | 3.part | 8h |
| 49 | 5.4 | Tillæg 1 sendes til Sikkerhed |  | 10d | 2026-08-26 | 2026-09-08 | 48 | 0d | LT PRO | 80h |
| 50 | 5.5 | Behandling hos Sikkerhed | milestone | 0d | 2026-09-08 | 2026-09-08 | 49 | 0d | LT SIK |  |
| 51 | 5.6 | Opdatering iht. kommentarer | milestone | 0d | 2026-09-08 | 2026-09-08 | 50 | 0d | 3.part |  |
| 52 | 5.7 | Review hos Lokaltog | milestone | 0d | 2026-09-08 | 2026-09-08 | 51 | 0d | LT PRO |  |
| 53 | 5.8 | Sikkerhed godkender Tillæg 1 |  | 15d | 2026-09-09 | 2026-09-29 | 52 | 0d | LT SIK | 120h |
| 54 | 5.9 | Lokaltog fremsender godkendelse |  | 15d | 2026-09-30 | 2026-10-20 | 53 | 0d | LT PRO | 120h |
